# CSF Upgrades and Migrations

Schedule from MS Project, 2013-01-14 to 2013-05-28, A marks actual dates.
MIT

## Calendars

- Standard: Mon-Fri 08:00-12:00, 13:00-17:00; Sat-Sun off.

## Resources

| Resource |
| --- |
| Dave |
| René |
| Steve |
| Felicia |
| Ram |
| Kevin |
| Brian |
| Janet |
| Seth |
| Lee |
| Faith |
| Peter |
| Felici |

## Schedule

| ID | WBS | Task | Type | Duration | Start | Finish | Predecessors | Complete | Remaining | Baseline start | Baseline finish | Baseline duration | Total slack | Free slack | Resources | Work | Actual work |
| --- | --- | --- | --- | --- | --- | --- | --- | --- | --- | --- | --- | --- | --- | --- | --- | --- | --- |
| 1 | 1 | Upgrade CSF to 2.0 |  | 10d | 2013-01-14 A | 2013-01-25 A |  | 100% |  |  |  |  |  |  |  |  |  |
| 2 | 2 | **Upgrade of Existing CSF Apps to CSF 2.0** |  | 40d? | 2013-01-14 A | 2013-03-08 |  | 11% | 35.79d? | 2013-02-13 | 2013-03-08 | 18d? | 56d |  |  | 135.2h | 16h |
| 3 | 2.1 | **Development** |  | 18d | 2013-02-13 A | 2013-03-08 |  | 20% | 14.4d | 2013-02-13 | 2013-03-08 | 18d | 56d |  |  | 80h | 16h |
| 4 | 2.1.1 | Upgrade IAP |  | 4d | 2013-02-14 | 2013-02-20 | 1FS+13d |  |  | 2013-02-14 | 2013-02-20 | 4d | 60d | 0d | Steve [50%] | 16h |  |
| 5 | 2.1.2 | Upgrade Subject Evaluation |  | 4d | 2013-02-26 | 2013-03-01 | 4FS+3d |  |  | 2013-02-26 | 2013-03-01 | 4d | 60d | 5d | Steve [50%] | 16h |  |
| 6 | 2.1.3 | Upgrade Sponsor Billing |  | 4d | 2013-02-13 A | 2013-02-19 A | 1FS+12d | 100% |  | 2013-02-13 | 2013-02-19 | 4d |  |  | Dave [50%] | 16h | 16h |
| 7 | 2.1.4 | Upgrade Survey Engine |  | 4d | 2013-02-26 | 2013-03-01 | 6FS+4d |  |  | 2013-02-26 | 2013-03-01 | 4d | 55d | 0d | Dave [50%] | 16h |  |
| 8 | 2.1.5 | Upgrade Subject Evaluation Report |  | 4d | 2013-03-05 | 2013-03-08 | 7FS+1d |  |  | 2013-03-05 | 2013-03-08 | 4d | 55d | 0d | Dave [50%] | 16h |  |
| 9 | 2.1.6 | Upgrades complete | milestone | 0d | 2013-03-08 | 2013-03-08 | 4, 5, 6, 7, 8 |  |  | 2013-03-08 | 2013-03-08 | 0d | 56d |  | Dave [50%]; Steve [50%] |  |  |
| 10 | 2.2 | **Testing** |  | 34d? | 2013-01-14 | 2013-02-28 |  |  |  |  |  |  | 62d |  |  | 31.2h |  |
| 11 | 2.2.1 | **Test Planning** |  | 4d? | 2013-02-20 | 2013-02-25 |  |  |  |  |  |  | 62d |  |  | 15.6h |  |
| 12 | 2.2.1.1 | IAP and Sponsor Billing |  | 3d | 2013-02-20 | 2013-02-22 | 4SS+4d |  |  |  |  |  | 62d | 0d | Seth [25%]; Faith [25%] | 7.6h |  |
| 13 | 2.2.1.2 | OFS Applications |  | 1d? | 2013-02-25 | 2013-02-25 | 12 |  |  |  |  |  | 63d | 0d | Lee | 8h |  |
| 14 | 2.2.1.3 | Test Planning Complete | milestone | 0d | 2013-02-25 | 2013-02-25 | 12, 13 |  |  |  |  |  | 64d | 2d |  |  |  |
| 15 | 2.2.2 | **BA Testing** |  | 3d? | 2013-02-25 | 2013-02-27 |  |  |  |  |  |  | 62d |  |  | 15.6h |  |
| 16 | 2.2.2.1 | IAP and Sponsor Billing |  | 3d | 2013-02-25 | 2013-02-27 | 12 |  |  |  |  |  | 62d | 0d | Seth [25%]; Faith [25%] | 7.6h |  |
| 17 | 2.2.2.2 | OFS Applications |  | 1d? | 2013-02-26 | 2013-02-26 | 13 |  |  |  |  |  | 63d | 1d | Lee | 8h |  |
| 18 | 2.2.2.3 | BA Testing Complete | milestone | 0d | 2013-02-27 | 2013-02-27 | 16, 17 |  |  |  |  |  | 62d | 0d |  |  |  |
| 19 | 2.2.3 | **UAT** |  | 1d? | 2013-01-14 | 2013-01-14 |  |  |  |  |  |  | 94d |  |  |  |  |
| 20 | 2.2.3.1 | IAP |  | 1d? | 2013-01-14 | 2013-01-14 |  |  |  |  |  |  | 94d | 0d |  |  |  |
| 21 | 2.2.3.2 | Subject Evaluation |  | 1d? | 2013-01-14 | 2013-01-14 |  |  |  |  |  |  | 94d | 0d |  |  |  |
| 22 | 2.2.3.3 | Sponsor Billing |  | 1d? | 2013-01-14 | 2013-01-14 |  |  |  |  |  |  | 94d | 0d |  |  |  |
| 23 | 2.2.3.4 | Survey Engine |  | 1d? | 2013-01-14 | 2013-01-14 |  |  |  |  |  |  | 94d | 0d |  |  |  |
| 24 | 2.2.3.5 | Subject Evaluation Report |  | 1d? | 2013-01-14 | 2013-01-14 |  |  |  |  |  |  | 94d | 0d |  |  |  |
| 25 | 2.2.3.6 | UAT Complete | milestone | 0d | 2013-01-14 | 2013-01-14 | 20, 21, 22, 23, 24 |  |  |  |  |  | 94d | 32d |  |  |  |
| 26 | 2.2.4 | Testing Efforts Complete |  | 1d? | 2013-02-28 | 2013-02-28 | 14, 18, 25 |  |  |  |  |  | 62d |  |  |  |  |

| ID | WBS | Task | Type | Duration | Start | Finish | Predecessors | Complete | Remaining | Baseline start | Baseline finish | Baseline duration | Total slack | Free slack | Resources | Work | Actual work |
| --- | --- | --- | --- | --- | --- | --- | --- | --- | --- | --- | --- | --- | --- | --- | --- | --- | --- |
| 27 | 2.3 | **Deployment Preparation** |  | 1d? | 2013-01-14 | 2013-01-14 |  |  |  |  |  |  | 94d |  |  | 24h |  |
| 28 | 2.3.1 | Create deployment plan |  | 1d? | 2013-01-14 | 2013-01-14 |  |  |  |  |  |  | 94d |  | René | 8h |  |
| 29 | 2.3.2 | Review deployment plan with participants |  | 1d? | 2013-01-14 | 2013-01-14 |  |  |  |  |  |  | 94d |  | René | 8h |  |
| 30 | 2.3.3 | Create registration support plan |  | 1d? | 2013-01-14 | 2013-01-14 |  |  |  |  |  |  | 94d |  | René | 8h |  |
| 31 | 2.4 | **Go-live** |  | 1d? | 2013-01-14 | 2013-01-14 |  |  |  |  |  |  | 95d |  |  |  |  |
| 32 | 2.4.1 | Prod smoke test |  | 1d? | 2013-01-14 | 2013-01-14 |  |  |  |  |  |  | 95d | 0d |  |  |  |
| 33 | 2.5 | Upgrade of Existing CSF Apps to CSF 2.0 Complete | milestone | 0d | 2013-01-14 | 2013-01-14 | 32 |  |  |  |  |  | 95d |  |  |  |  |
| 34 | 3 | **Convert SAIS-Common Apps to CSF 2.0** |  | 1d? | 2013-01-14 | 2013-01-14 |  |  |  |  |  |  | 95d |  |  |  |  |
| 35 | 3.1 | Development |  | 1d? | 2013-01-14 | 2013-01-14 |  |  |  |  |  |  | 95d |  |  |  |  |
| 36 | 3.2 | Testing |  | 1d? | 2013-01-14 | 2013-01-14 |  |  |  |  |  |  | 95d |  |  |  |  |
| 37 | 4 | **PE REG Upgrade** |  | 44d? | 2013-01-14 A | 2013-03-14 |  | 17% | 36.67d? | 2013-02-07 | 2013-03-07 | 21d? | 52d |  |  | 176h | 40h |
| 38 | 4.1 | **Phase I - Java 6, Touchstone, and CSF Enabling** |  | 26d? | 2013-02-07 A | 2013-03-14 |  | 20% | 20.8d? | 2013-02-07 | 2013-03-07 | 21d? | 52d |  |  | 160h | 40h |
| 39 | 4.1.1 | **Development** |  | 21d | 2013-02-07 A | 2013-03-07 |  | 25% | 15.75d | 2013-02-07 | 2013-03-07 | 21d | 52d |  |  | 160h | 40h |
| 40 | 4.1.1.1 | Do set-up and configuration required for upgrade |  | 5d | 2013-02-07 A | 2013-02-13 A |  | 100% |  | 2013-02-07 | 2013-02-13 | 5d |  |  | Ram | 40h | 40h |
| 41 | 4.1.1.2 | Perform upgrade |  | 5d | 2013-02-14 | 2013-02-21 | 40 |  |  | 2013-02-14 | 2013-02-21 | 5d | 52d | 0d | Ram | 40h |  |
| 42 | 4.1.1.3 | Unit test changes |  | 10d | 2013-02-22 | 2013-03-07 | 41 |  |  | 2013-02-22 | 2013-03-07 | 10d | 52d | 0d | Ram | 80h |  |
| 43 | 4.1.2 | **Testing** |  | 4d? | 2013-03-08 | 2013-03-13 |  |  |  |  |  |  | 52d |  |  |  |  |
| 44 | 4.1.2.1 | Test planning |  | 1d? | 2013-03-08 | 2013-03-08 | 42 |  |  |  |  |  | 52d | 0d |  |  |  |
| 45 | 4.1.2.2 | QA testing |  | 1d? | 2013-03-11 | 2013-03-11 | 44 |  |  |  |  |  | 52d | 0d |  |  |  |
| 46 | 4.1.2.3 | Load testing |  | 1d? | 2013-03-12 | 2013-03-12 | 45 |  |  |  |  |  | 52d | 0d |  |  |  |
| 47 | 4.1.2.4 | User |  | 1d? | 2013-03-13 | 2013-03-13 | 46 |  |  |  |  |  | 52d | 0d |  |  |  |
| 48 | 4.1.3 | Go-live |  | 1d? | 2013-03-14 | 2013-03-14 | 47 |  |  |  |  |  | 52d | 0d |  |  |  |
| 49 | 4.2 | **Phase II - Full CSF Upgrade** |  | 41d? | 2013-01-14 | 2013-03-11 |  |  |  |  |  |  | 55d |  |  | 16h |  |
| 50 | 4.2.1 | **Development** |  | 2d? | 2013-03-08 | 2013-03-11 |  |  |  |  |  |  | 54d |  |  | 16h |  |
| 51 | 4.2.1.1 | Perform full upgrade |  | 1d? | 2013-03-08 | 2013-03-08 | 42 |  |  |  |  |  | 54d | 0d | Ram | 8h |  |
| 52 | 4.2.1.2 | Unit test changes |  | 1d? | 2013-03-11 | 2013-03-11 | 51 |  |  |  |  |  | 54d |  | Ram | 8h |  |

| ID | WBS | Task | Type | Duration | Start | Finish | Predecessors | Baseline start | Baseline finish | Baseline duration | Total slack | Free slack | Constraint | Resources | Work |
| --- | --- | --- | --- | --- | --- | --- | --- | --- | --- | --- | --- | --- | --- | --- | --- |
| 53 | 4.2.2 | **Testing** |  | 1d? | 2013-01-14 | 2013-01-14 |  |  |  |  | 95d |  |  |  |  |
| 54 | 4.2.2.1 | QA |  | 1d? | 2013-01-14 | 2013-01-14 |  |  |  |  | 95d |  |  |  |  |
| 55 | 4.2.2.2 | User |  | 1d? | 2013-01-14 | 2013-01-14 |  |  |  |  | 95d |  |  |  |  |
| 56 | 4.2.3 | Go-live |  | 1d? | 2013-01-14 | 2013-01-14 |  |  |  |  | 95d | 43d |  |  |  |
| 57 | 4.3 | PE REG upgrade complete | milestone | 0d | 2013-03-14 | 2013-03-14 | 48, 56 |  |  |  | 52d |  |  | Ram |  |
| 58 | 5 | **Convert OREG to CSF 2.0** |  | 76d | 2013-02-11 | 2013-05-28 |  | 2013-02-11 | 2013-05-28 | 76d | 0d |  |  |  | 624h |
| 59 | 5.1 | **Development (including unit testing)** |  | 35d | 2013-02-11 | 2013-03-29 |  | 2013-02-11 | 2013-03-22 | 29d | 0d |  |  |  | 272h |
| 60 | 5.1.1 | Phase 1 - Required as-is , high priority (A/D and OREG) |  | 9d | 2013-02-11 | 2013-02-22 |  |  |  |  | 0d |  | start no earlier than 2013-02-11 | Felicia | 72h |
| 61 | 5.1.2 | Phase 2 - Medium priority validation and messaging |  | 15d | 2013-02-25 | 2013-03-15 | 60 |  |  |  | 0d |  |  | Felicia | 120h |
| 62 | 5.1.3 | Phase 3 - Stabilize JAR and rafactor CSF dependencies |  | 5d | 2013-03-18 | 2013-03-22 | 61 |  |  |  | 0d |  |  | Felicia | 40h |
| 63 | 5.1.4 | Phase 4 - Modify OREG to use new JAR and upgrade to CSF 2.0 |  | 5d | 2013-03-25 | 2013-03-29 | 62 |  |  |  | 0d |  |  | Felicia | 40h |
| 64 | 5.1.5 | Development complete | milestone | 0d | 2013-03-29 | 2013-03-29 | 63 |  |  |  | 0d |  |  | Felicia |  |
| 65 | 5.2 | Regression Testing |  | 24d | 2013-04-01 | 2013-05-03 | 64 | 2013-03-25 | 2013-04-26 | 24d | 0d |  |  | Kevin | 192h |
| 66 | 5.3 | UAT |  | 20d | 2013-04-29 | 2013-05-24 | 65FS-5d | 2013-04-29 | 2013-05-24 | 20d | 0d |  |  | Brian | 160h |
| 67 | 5.4 | Go-live | milestone | 0d | 2013-05-28 | 2013-05-28 |  | 2013-05-28 | 2013-05-28 | 0d | 0d |  | start no earlier than 2013-05-28 | René |  |
| 68 | 6 | **Notes Utility Beta** |  | 96d? | 2013-01-14 | 2013-05-28 |  |  |  |  | 0d |  |  |  | 8h |
| 69 | 6.1 | Development |  | 1d? | 2013-04-01 | 2013-04-01 | 59 |  |  |  | 39d |  |  | Felicia | 8h |
| 70 | 6.2 | UAT |  | 1d? | 2013-01-14 | 2013-01-14 |  |  |  |  | 95d |  |  |  |  |
| 71 | 6.3 | Go-live | milestone | 0d | 2013-05-28 | 2013-05-28 |  |  |  |  | 0d |  | start no earlier than 2013-05-28 | René |  |
| 72 | 6.4 | Requirements |  | 1d? | 2013-01-14 | 2013-01-14 |  |  |  |  | 95d |  |  |  |  |
| 73 | 6.5 | Functional Specification |  | 1d? | 2013-01-14 | 2013-01-14 |  |  |  |  | 95d |  |  |  |  |
| 74 | 6.6 | **Technical Analysis and Design - Spring Messages** |  | 3d | 2013-01-14 | 2013-01-16 |  |  |  |  | 93d |  |  |  |  |
| 75 | 6.6.1 | Write Technical Specification |  | 3d | 2013-01-14 | 2013-01-16 |  |  |  |  | 93d |  |  |  |  |
| 76 | 6.6.2 | Review Technical Specification with Technical Team | milestone | 0d | 2013-01-14 | 2013-01-14 |  |  |  |  | 96d |  |  |  |  |
| 77 | 6.6.3 | Update Specification based on feedback |  | 2d | 2013-01-14 | 2013-01-15 |  |  |  |  | 94d |  |  |  |  |
| 78 | 6.6.4 | Technical Analysis and Design Complete | milestone | 0d | 2013-01-14 | 2013-01-14 |  |  |  |  | 96d |  |  |  |  |

| ID | WBS | Task | Type | Duration | Start | Finish | Total slack |
| --- | --- | --- | --- | --- | --- | --- | --- |
| 79 | 6.7 | **Technical Analysis and Design - Rules Engine/OREG Decoupling** |  | 10d | 2013-01-14 | 2013-01-25 | 86d |
| 80 | 6.7.1 | Write Technical Specification |  | 10d | 2013-01-14 | 2013-01-25 | 86d |
| 81 | 6.8 | **Development** |  | 11d | 2013-01-14 | 2013-01-28 | 85d |
| 82 | 6.8.1 | **OREG** |  | 11d | 2013-01-14 | 2013-01-28 | 85d |
| 83 | 6.8.1.1 | Rules Engine/OREG Decoupling and integration testing |  | 5d | 2013-01-14 | 2013-01-18 | 91d |
| 84 | 6.8.1.2 | Common Changes (Desktop and Mobile) |  | 11d | 2013-01-14 | 2013-01-28 | 85d |
| 85 | 6.8.1.3 | Desktop Only Changes |  | 1d | 2013-01-14 | 2013-01-14 | 95d |
| 86 | 6.8.1.4 | Enter rules and data into database |  | 1d | 2013-01-14 | 2013-01-14 | 95d |
| 87 | 6.8.1.5 | Unit Test (Phase 2 to test code against UI) |  | 11d | 2013-01-14 | 2013-01-28 | 85d |
| 88 | 6.8.1.6 | Code review |  | 0.5d | 2013-01-14 | 2013-01-14 | 95.5d |
| 89 | 6.8.1.7 | OREG development complete | milestone | 0d | 2013-01-14 | 2013-01-14 | 96d |
| 90 | 6.8.2 | **Jira Tickets** |  | 11d | 2013-01-14 | 2013-01-28 | 85d |
| 91 | 6.8.2.1 | **Bundle 1** |  | 11d | 2013-01-14 | 2013-01-28 | 85d |
| 92 | 6.8.2.1.1 | 1050-Prod: Students with enroll status = FS can access oreg/fixing summary report so fss students won't be counted. |  | 3d | 2013-01-14 | 2013-01-16 | 93d |
| 93 | 6.8.2.1.2 | 1047-Prod: Term address in OREG not in sycnh with websis |  | 5d | 2013-01-14 | 2013-01-18 | 91d |
| 94 | 6.8.2.1.3 | 1055-Old phone number appearing on addressess |  | 11d | 2013-01-14 | 2013-01-28 | 85d |
| 95 | 6.8.2.2 | **Bundle 2** |  | 6d | 2013-01-14 | 2013-01-21 | 90d |
| 96 | 6.8.2.2.1 | 1036-Advisor landing page: status column sort error |  | 6d | 2013-01-14 | 2013-01-21 | 90d |
| 97 | 6.8.2.2.2 | 1042-Change approval process for mobile approvals |  | 2d | 2013-01-14 | 2013-01-15 | 94d |
| 98 | 6.8.2.2.3 | 1046-Prod: Freshman Folder link not working for admins |  | 2d | 2013-01-14 | 2013-01-15 | 94d |
| 99 | 6.8.2.2.4 | 1052-GASP status adjustment |  | 2d | 2013-01-14 | 2013-01-15 | 94d |
| 100 | 6.8.2.2.5 | 1054-Auto save when subject is added |  | 1d | 2013-01-14 | 2013-01-14 | 95d |
| 101 | 6.8.2.2.6 | 1053-Adjust messaging for 18.01A and 18.02A (includes mobile) |  | 2d | 2013-01-14 | 2013-01-15 | 94d |
| 102 | 6.8.2.2.7 | 1056--Report Summary By Date CSV and PDF Downloads Incorrect |  | 1d | 2013-01-14 | 2013-01-14 | 95d |
| 103 | 6.8.2.3 | Jira development complete | milestone | 0d | 2013-01-14 | 2013-01-14 | 96d |
| 104 | 6.8.3 | Development of new requirements for spring messaging |  | 9d | 2013-01-14 | 2013-01-24 | 87d |

| ID | WBS | Task | Type | Duration | Start | Finish | Total slack |
| --- | --- | --- | --- | --- | --- | --- | --- |
| 105 | 6.9 | **Test Preparation** |  | 25d? | 2013-01-14 | 2013-02-15 | 71d |
| 106 | 6.9.1 | Identify data needs - 1st draft |  | 5d | 2013-01-14 | 2013-01-18 | 91d |
| 107 | 6.9.2 | Build test suite in QC |  | 2d | 2013-01-14 | 2013-02-01 | 81.6d |
| 108 | 6.9.3 | Write test cases |  | 15d | 2013-01-14 | 2013-02-01 | 81d |
| 109 | 6.9.4 | Review test cases with team |  | 1d? | 2013-01-14 | 2013-01-14 | 95d |
| 110 | 6.9.5 | Update test cases based on feedback |  | 25d | 2013-01-14 | 2013-02-15 | 71d |
| 111 | 6.9.6 | Identify data needs - final draft |  | 25d | 2013-01-14 | 2013-02-15 | 71d |
| 112 | 6.9.7 | PRDE is rolled to fall (spring population available) |  | 1d | 2013-01-14 | 2013-01-14 | 95d |
| 113 | 6.9.8 | Refresh TEST database |  | 1d | 2013-01-14 | 2013-01-14 | 95d |
| 114 | 6.9.9 | Do data mining |  | 13d | 2013-01-14 | 2013-01-30 | 83d |
| 115 | 6.9.10 | Test preparation complete | milestone | 0d | 2013-01-14 | 2013-01-14 | 96d |
| 116 | 6.9.11 | Write test cases for new requirements for spring messaging (includes data requirements analysis) |  | 5d | 2013-01-14 | 2013-01-18 | 91d |
| 117 | 6.10 | **Systems Integration Test** |  | 15d | 2013-01-14 | 2013-02-01 | 81d |
| 118 | 6.10.1 | **OREG** |  | 15d | 2013-01-14 | 2013-02-01 | 81d |
| 119 | 6.10.1.1 | Execute test cases |  | 15d | 2013-01-14 | 2013-02-01 | 81d |
| 120 | 6.10.1.2 | Bugfixing |  | 9d | 2013-01-14 | 2013-01-24 | 87d |
| 121 | 6.10.2 | **Jira tickets** |  | 12d | 2013-01-14 | 2013-01-29 | 84d |
| 122 | 6.10.2.1 | **Bundle 1** |  | 12d | 2013-01-14 | 2013-01-29 | 84d |
| 123 | 6.10.2.1.1 | Execute test cases |  | 12d | 2013-01-14 | 2013-01-29 | 84d |
| 124 | 6.10.2.1.2 | Bugfixing |  | 11d | 2013-01-14 | 2013-01-28 | 85d |
| 125 | 6.10.2.2 | **Bundle 2** |  | 11d | 2013-01-14 | 2013-01-28 | 85d |
| 126 | 6.10.2.2.1 | Execute test cases |  | 11d | 2013-01-14 | 2013-01-28 | 85d |
| 127 | 6.10.2.2.2 | Bugfixing |  | 11d | 2013-01-14 | 2013-01-28 | 85d |
| 128 | 6.11 | Regression Testing |  | 15d | 2013-01-14 | 2013-02-01 | 81d |
| 129 | 6.12 | SIT of new requirements for spring messaging |  | 4d | 2013-01-14 | 2013-01-17 | 92d |
| 130 | 6.13 | End to end testing (includes 1052 and RT 2107132 (gasp3 lock script)) |  | 2d | 2013-01-14 | 2013-01-15 | 94d |
| 131 | 6.14 | Load Testing |  | 1d | 2013-01-14 | 2013-01-14 | 95d |
| 132 | 6.15 | User Acceptance Test |  | 1d? | 2013-01-14 | 2013-01-14 | 95d |

| ID | WBS | Task | Type | Duration | Start | Finish | Total slack |
| --- | --- | --- | --- | --- | --- | --- | --- |
| 133 | 6.16 | **Deployment Preparation** |  | 13d? | 2013-01-14 | 2013-01-30 | 83d |
| 134 | 6.16.1 | Create deployment plan |  | 5d | 2013-01-14 | 2013-01-18 | 91d |
| 135 | 6.16.2 | Review deployment plan with participants |  | 1d? | 2013-01-14 | 2013-01-14 | 95d |
| 136 | 6.16.3 | Create registration support plan |  | 13d | 2013-01-14 | 2013-01-30 | 83d |
| 137 | 6.17 | Go-live | milestone | 0d | 2013-01-14 | 2013-01-14 | 96d |
| 138 | 6.18 | Prod smoke test |  | 5d | 2013-01-14 | 2013-01-18 | 91d |
| 139 | 6.19 | Registration opens | milestone | 0d | 2013-01-14 | 2013-01-14 | 96d |
| 140 | 6.20 | Registration support |  | 10d | 2013-01-14 | 2013-01-25 | 86d |
